# Propuesta de Diseño

How a schedule from MS Project changed from version to version. A marks actual dates.

## Version 1 (saved 2007-09-13, file 20070913-1189698651.mpp)

| ID | WBS | Task | Duration | Start | Finish | Predecessors | Total float | Constraint |
| --- | --- | --- | --- | --- | --- | --- | --- | --- |
| 1 | 1 | **Proyecto Sitio Web - Vida Profesional** | 41.75d? | 2007-09-04 | 2007-11-01 |  | 0d |  |
| 2 |  | Preparación y Reunión Kickoff (Inicio Proyecto) | 0.38d | 2007-09-04 | 2007-09-04 |  | 41.38d | start no earlier than 2007-09-04 |
| 3 |  | Reservación dominio desarrollo, configuración y creación Sitio WIB | 0.5d? | 2007-09-10 | 2007-09-10 |  | 0d | start no earlier than 2007-09-10 |
| 4 |  | Elaboración de Plan y Documento de Alcance | 1d? | 2007-09-10 | 2007-09-11 | 3 | 0.9d |  |
| 5 | 1.4 | **Informe de Especificación de Requerimientos** | 6d | 2007-09-10 | 2007-09-18 |  | 0d |  |
| 6 |  | Elaboración del Informe de Especificación de Requerimientos | 4d | 2007-09-10 | 2007-09-14 | 3 | 0d | start no earlier than 2007-09-05 |
| 7 |  | Entrega al Equipo de Proyecto Sodexho para su revisión | 0d | 2007-09-14 | 2007-09-14 | 6 | 0d | start no earlier than 2007-08-02 |
| 8 |  | Revisión por parte del Equipo de Proyecto Sodexho | 2d | 2007-09-14 | 2007-09-18 | 7 | 0d | start no earlier than 2007-06-06 |
| 9 |  | Aprobación del Informe Especificación de Requerimientos | 0d | 2007-09-18 | 2007-09-18 | 8 | 0d | start no earlier than 2007-06-15 |
| 10 | 1.5 | **Diseño Website e implementación WIB** | 34d? | 2007-09-11 | 2007-10-30 |  | 2.25d |  |
| 11 | 1.5.1 | **WIB** | 25.5d? | 2007-09-11 | 2007-10-17 |  | 2.25d |  |
| 12 | 1.5.1.1 | **Diseño Pagina Principal** | 3d? | 2007-09-11 | 2007-09-14 |  | 2.25d |  |
| 13 |  | Proximos Eventos | 0.5d? | 2007-09-11 | 2007-09-11 | 4 | 2.25d |  |
| 14 |  | Lo Ultimo | 0.5d? | 2007-09-12 | 2007-09-12 | 13 | 2.25d |  |
| 15 |  | Enlaces a Salas | 0.5d? | 2007-09-12 | 2007-09-12 | 14 | 2.25d |  |
| 16 |  | Calendario | 0.75d? | 2007-09-13 | 2007-09-13 | 15 | 2.25d |  |
| 17 |  | Afiliados | 0.5d? | 2007-09-13 | 2007-09-14 | 16 | 2.25d |  |
| 18 |  | Montaje Banner Principal elaborado por Sodexho | 0.25d? | 2007-09-14 | 2007-09-14 | 17 | 2.25d |  |
| 19 | 1.5.1.2 | **Diseño Eventos** | 2.75d? | 2007-09-14 | 2007-09-19 |  | 2.25d |  |
| 20 |  | Listado de Eventos | 0.5d? | 2007-09-14 | 2007-09-14 | 12 | 2.25d |  |
| 21 |  | Detalle de los Eventos | 0.5d? | 2007-09-17 | 2007-09-17 | 20 | 2.25d |  |
| 22 |  | Planilla de Inscripción | 0.75d? | 2007-09-17 | 2007-09-18 | 21 | 2.25d |  |
| 23 |  | Planilla de Pago | 1d? | 2007-09-18 | 2007-09-19 | 22 | 2.25d |  |
| 24 |  | Mensaje de Información para Usuario | 0.5d? | 2007-09-19 | 2007-09-19 | 19 | 2.25d |  |
| 25 | 1.5.1.4 | **Diseño Salas** | 4.5d? | 2007-09-19 | 2007-09-26 |  | 2.25d |  |
| 26 |  | Descripcion de la Sala (Parrafo Libre) | 0.25d? | 2007-09-19 | 2007-09-19 | 24 | 2.25d |  |
| 27 |  | Blog (Paquetizado) | 1d? | 2007-09-20 | 2007-09-20 | 26 | 2.25d |  |
| 28 |  | Ultimos 6 Elementos de Información | 1.5d? | 2007-09-21 | 2007-09-24 | 27 | 2.25d |  |
| 29 | 1.5.1.4.4 | **Buscador Avanzado** | 1.75d? | 2007-09-24 | 2007-09-26 |  | 2.25d |  |
| 30 |  | Formulario | 0.75d? | 2007-09-24 | 2007-09-25 | 28 | 2.25d |  |
| 31 |  | Resultados | 1d? | 2007-09-25 | 2007-09-26 | 30 | 2.25d |  |
| 32 | 1.5.1.5 | **Informacion Util** | 0.5d? | 2007-09-26 | 2007-09-26 |  | 2.25d |  |
| 33 |  | Informacion Util | 0.5d? | 2007-09-26 | 2007-09-26 | 25 | 2.25d |  |
| 34 | 1.5.1.6 | **Servicios** | 2d? | 2007-09-26 | 2007-09-28 |  | 2.25d |  |
| 35 |  | Buscador | 1d? | 2007-09-26 | 2007-09-27 | 32 | 2.25d |  |
| 36 |  | Pagina Detalle | 1d? | 2007-09-27 | 2007-09-28 | 35 | 2.25d |  |
| 37 |  | Encabezado para Mail | 0.5d? | 2007-09-28 | 2007-10-01 | 34 | 2.25d |  |
| 38 | 1.5.1.8 | **Formatos** | 0.5d? | 2007-10-01 | 2007-10-01 |  | 2.25d |  |
| 39 |  | Lista de documentos disponibles para ser descargados | 0.5d? | 2007-10-01 | 2007-10-01 | 37 | 2.25d |  |
| 40 | 1.5.1.9 | **Herramientas** | 2.5d? | 2007-10-01 | 2007-10-04 |  | 2.25d |  |
| 41 |  | Calculadora de Inflacion | 1.25d? | 2007-10-01 | 2007-10-02 | 38 | 2.25d |  |
| 42 |  | Calculadora Financiera | 1.25d? | 2007-10-03 | 2007-10-04 | 41 | 2.25d |  |
| 43 | 1.5.1.10 | **Formularios** | 3d? | 2007-10-04 | 2007-10-09 |  | 2.25d |  |
| 44 |  | Formulario de Contacto | 1.5d? | 2007-10-04 | 2007-10-05 | 40 | 2.25d |  |
| 45 |  | Formulario de Registro | 1.5d? | 2007-10-05 | 2007-10-09 | 44 | 2.25d |  |
| 46 | 1.5.1.11 | **Mapa del Sitio** | 0.25d? | 2007-10-09 | 2007-10-09 |  | 2.25d |  |
| 47 |  | Mapa del Sitio | 0.25d? | 2007-10-09 | 2007-10-09 | 43 | 2.25d |  |
| 48 | 1.5.1.12 | **Quien es Quien** | 0.5d? | 2007-10-09 | 2007-10-09 |  | 2.25d |  |
| 49 |  | Formato de Hoja de Vida | 0.5d? | 2007-10-09 | 2007-10-09 | 46 | 2.25d |  |
| 50 | 1.5.1.13 | **Encuestas** | 1d? | 2007-10-10 | 2007-10-10 |  | 2.25d |  |
| 51 |  | Formato de Encuestas | 1d? | 2007-10-10 | 2007-10-10 | 48 | 2.25d |  |
| 52 | 1.5.1.14 | **Plantillas** | 4d? | 2007-10-11 | 2007-10-17 |  | 2.25d |  |
| 53 |  | Plantilla 1 | 1d? | 2007-10-11 | 2007-10-11 | 50 | 2.25d |  |
| 54 |  | Plantilla 2 | 1d? | 2007-10-15 | 2007-10-15 | 53 | 2.25d |  |
| 55 |  | Plantilla 3 | 1d? | 2007-10-16 | 2007-10-16 | 54 | 2.25d |  |
| 56 |  | Plantilla 4 | 1d? | 2007-10-17 | 2007-10-17 | 55 | 2.25d |  |
| 57 | 1.5.2 | **Net2Client** | 2.5d? | 2007-10-18 | 2007-10-22 |  | 2.25d |  |
| 58 |  | Revision y Adaptacion de CSS de Backoffice | 2.5d? | 2007-10-18 | 2007-10-22 | 52 | 2.25d |  |
| 59 |  | Adaptacion de Hoja a Firefox | 6d? | 2007-10-22 | 2007-10-30 | 57 | 2.25d |  |
| 60 | 1.6 | **Desarrollo y Configuración de Funcionalidades** | 29.23d? | 2007-09-11 | 2007-10-23 |  | 0.9d |  |
| 61 | 1.6.1 | **Análisis y Diseño de funcionalidades y backoffice** | 3.6d | 2007-09-11 | 2007-09-17 |  | 0.9d |  |
| 62 |  | Análisis | 1.6d | 2007-09-11 | 2007-09-13 | 4 | 0.9d |  |
| 63 |  | Modelaje de Base de Datos | 2d | 2007-09-13 | 2007-09-17 | 62 | 1.82d |  |
| 64 | 1.6.2 | **Funcionalidades del Sitio Web** | 25.62d? | 2007-09-17 | 2007-10-23 |  | 1.82d |  |
| 65 | 1.6.2.1 | **BackOffice** | 10d? | 2007-09-17 | 2007-10-01 |  | 1.82d |  |
| 66 |  | Registro y Actualización de Cursos | 0.62d? | 2007-09-17 | 2007-09-17 | 61 | 11.2d |  |
| 67 |  | Creación y Configuración de Salas | 1.25d? | 2007-09-17 | 2007-09-18 | 61 | 8.07d |  |
| 68 |  | Artículos por Sala | 1.25d? | 2007-09-18 | 2007-09-19 | 67 | 8.07d |  |
| 69 |  | Administración de Banners | 1.25d? | 2007-09-19 | 2007-09-24 | 68 | 6.07d |  |
| 70 |  | Registro de Servicios | 1d? | 2007-09-17 | 2007-09-18 | 61 | 1.82d |  |

| ID | WBS | Task | Duration | Start | Finish | Predecessors | Total float |
| --- | --- | --- | --- | --- | --- | --- | --- |
| 71 |  | Manejo de Contenido de Artículos de Blogs | 4d | 2007-09-18 | 2007-09-26 | 70 | 1.82d |
| 72 |  | Quién es Quién | 2d? | 2007-09-26 | 2007-09-28 | 71 | 1.82d |
| 73 |  | Módulo Contáctenos | 1d? | 2007-09-28 | 2007-10-01 | 72 | 1.82d |
| 74 | 1.6.2.2 | **General** | 5d? | 2007-10-01 | 2007-10-08 |  | 1.82d |
| 75 |  | Registro de Cliente | 1.25d | 2007-10-01 | 2007-10-02 | 65 | 1.82d |
| 76 |  | Login | 0.62d? | 2007-10-02 | 2007-10-02 | 75 | 1.82d |
| 77 |  | Buscador General | 0.62d? | 2007-10-02 | 2007-10-03 | 76 | 1.82d |
| 78 |  | Banners | 2.5d? | 2007-10-03 | 2007-10-08 | 77 | 1.82d |
| 79 |  | Tópico de Interés | 0.62d? | 2007-10-01 | 2007-10-01 | 73 | 5.95d |
| 80 |  | Encuestas | 1.25d? | 2007-10-01 | 2007-10-02 | 79 | 5.95d |
| 81 |  | Contáctanos | 0.62d? | 2007-10-02 | 2007-10-03 | 80 | 5.95d |
| 82 |  | Mapa del Sitio | 0.25d? | 2007-10-03 | 2007-10-03 | 81 | 5.95d |
| 83 | 1.6.2.3 | **Página Principal** | 16.25d? | 2007-09-17 | 2007-10-09 |  | 4.32d |
| 84 |  | Lo que viene (despliegue de datos básicos de hasta 3 eventos) | 0.62d? | 2007-10-08 | 2007-10-08 | 78 | 1.82d |
| 85 |  | Lo último (artículos de información recientes) | 0.62d? | 2007-10-08 | 2007-10-09 | 84 | 1.82d |
| 86 |  | Enlaces a las salas | 0.62d? | 2007-10-09 | 2007-10-09 | 85 | 1.82d |
| 87 |  | Afiliados (5 random) | 2.5d? | 2007-10-03 | 2007-10-08 | 82 | 5.95d |
| 88 |  | Calendario de Eventos | 5d? | 2007-09-17 | 2007-09-24 | 66 | 14.32d |
| 89 | 1.6.2.4 | **Eventos** | 7.5d? | 2007-09-24 | 2007-10-04 |  | 14.32d |
| 90 |  | Publicación de Cursos | 0.62d? | 2007-09-24 | 2007-09-25 | 88 | 14.32d |
| 91 |  | Inscripción y registro de pago de cursos | 5.62d? | 2007-09-25 | 2007-10-02 | 90 | 14.32d |
| 92 |  | Reservación y vencimiento | 1.25d? | 2007-10-02 | 2007-10-04 | 91 | 14.32d |
| 93 | 1.6.2.5 | **Salas** | 8.5d? | 2007-10-08 | 2007-10-19 |  | 2.45d |
| 94 |  | Lo Último (los 6 elementos de información recientes) | 2.5d? | 2007-10-09 | 2007-10-15 | 86 | 1.82d |
| 95 |  | Buscador | 3.75d? | 2007-10-15 | 2007-10-19 | 94 | 1.82d |
| 96 |  | Artículo aleatorio en Columna Derecha | 0.62d? | 2007-10-19 | 2007-10-19 | 95 | 1.82d |
| 97 |  | Blog | 2.5d? | 2007-10-08 | 2007-10-10 | 87 | 5.95d |
| 98 |  | Quién es quién | 2.5d? | 2007-10-10 | 2007-10-16 | 97 | 5.95d |
| 99 | 1.6.2.6 | **Información Útil** | 5.38d? | 2007-10-16 | 2007-10-23 |  | 1.82d |
| 100 |  | Teléfonos (Página de Contenido) | 0.62d? | 2007-10-16 | 2007-10-16 | 98 | 5.95d |
| 101 |  | Formatos | 0.62d? | 2007-10-16 | 2007-10-17 | 100 | 5.95d |
| 102 |  | Herramientas | 0.62d? | 2007-10-19 | 2007-10-22 | 96 | 1.82d |
| 103 |  | Servicios | 1.25d? | 2007-10-22 | 2007-10-23 | 102 | 1.82d |
| 104 |  | Carga de datos de Clientes en .CSV | 3d? | 2007-10-23 | 2007-10-26 | 64 | 4.03d |
| 105 |  | Pruebas Internas y ajustes | 0.95d | 2007-10-23 | 2007-10-24 | 64 | 1.82d |
| 106 |  | Pruebas de Certificación por parte del Cliente | 3d | 2007-10-24 | 2007-10-29 | 105 | 1.82d |
| 107 |  | Implementación (Pase a producción) | 1d | 2007-10-29 | 2007-10-30 | 106 | 1.82d |
| 108 |  | Guia de Usuario BackOffice | 2d | 2007-10-24 | 2007-10-26 | 105 | 3.07d |
| 109 |  | Inducción (preparación y adiestramiento) | 1d | 2007-10-26 | 2007-10-29 | 108 | 3.07d |
| 110 | 1.13 | **Gerencia de Proyectos** | 31.25d | 2007-09-18 | 2007-11-01 |  | 0d |
| 111 |  | Control y Seguimiento | 31.25d | 2007-09-18 | 2007-11-01 | 5 | 0d |
| 112 |  | Cierre | 0.25d | 2007-10-30 | 2007-10-30 | 107 | 1.82d |

## Version 2 (saved 2007-10-24, file 20071024-1193252319.mpp)

Last finish 2007-11-01 → 2007-11-27 (+26d). Complete tasks 0 → 43.

Added:

| ID | Task | Duration | Start | Finish | Predecessors | Constraint | Resources |
| --- | --- | --- | --- | --- | --- | --- | --- |
| 5 | Ajustes Documento de Alcance y Plan | 1.25d? | 2007-09-18 A | 2007-09-19 A |  | start no earlier than 2007-09-18 | GP [10%]; FA [10%]; DS1 [10%] |
| 13 | Creación y ajustes de Propuestas | 3.91d? | 2007-09-11 A | 2007-09-14 A |  | start no earlier than 2007-09-11 | FA [80%] |
| 16 | Artículo Aleatorio | 1d? | 2007-09-17 A | 2007-09-18 A | 15 |  |  |
| 17 | Despliegue de Banners | 0.16d? | 2007-09-19 A | 2007-09-19 A | 22 |  | FA [80%] |
| 43 | Plantilla para Teléfonos | 0.16d? | 2007-10-29 | 2007-10-29 | 40 |  | FA [80%] |
| 75 | Registro de Aliados | 0.62d? | 2007-10-25 | 2007-10-25 |  | start no earlier than 2007-10-25 | DS1 [80%] |
| 92 | Proforma de Pago | 2d? | 2007-11-05 | 2007-11-06 | 91 |  | DS3 [50%] |
| 94 | Envío por email de listado de Inscritos al Organizador | 2d? | 2007-11-09 | 2007-11-12 | 93 |  | DS3 [50%] |
| 99 | **Envío de Boletin** | 10d? | 2007-10-26 | 2007-11-09 |  |  |  |
| 100 | Desarrollo aplicación | 7.5d? | 2007-10-26 | 2007-11-07 | 78 |  | DS2 [40%] |
| 101 | Documentación Técnica | 1.25d? | 2007-11-07 | 2007-11-08 | 100 |  | DS2 [40%] |
| 102 | Guia de Usuario | 1.25d? | 2007-11-08 | 2007-11-09 | 101 |  | DS2 [40%] |
| 110 | El sitio Web ya puede ser utilizado com Piloto | 1d? | 2007-11-16 | 2007-11-19 | 109 |  |  |
| 115 | Configuración dominio Web | 0.5d? | 2007-11-26 | 2007-11-26 | 114 |  | OP |

Removed: 14 Lo Ultimo; 18 Montaje Banner Principal elaborado por Sodexho; 33 Informacion Util; 82 Mapa del Sitio; 84 Lo que viene (despliegue de datos básicos de hasta 3 eventos); 96 Artículo aleatorio en Columna Derecha; 100 Teléfonos (Página de Contenido); 101 Formatos

Changed:

| ID | Task | Start | Finish | Duration | Complete | Total float | Predecessors | Other |
| --- | --- | --- | --- | --- | --- | --- | --- | --- |
| 1 | **Proyecto Sitio Web - Vida Profesional** | 2007-09-04 A | 2007-11-01 → 2007-11-27 (+26d) | 41.75d? → 59.21d? | 0% → 35% |  |  |  |
| 2 | Preparación y Reunión Kickoff (Inicio Proyecto) | 2007-09-04 A | 2007-09-04 A |  | 0% → 100% | 41.38d → none |  |  |
| 3 | Reservación dominio desarrollo, configuración y creación Sitio WIB | 2007-09-10 A | 2007-09-10 A |  | 0% → 100% | 0d → none |  |  |
| 4 | Elaboración de Plan y Documento de Alcance | 2007-09-10 A | 2007-09-11 A |  | 0% → 100% | 0.9d → none |  |  |
| 6 | **Informe de Especificación de Requerimientos** | 2007-09-10 → 2007-09-19 A (+9d) | 2007-09-18 → 2007-09-27 A (+9d) |  | 0% → 100% | 0d → none |  |  |
| 7 | Elaboración del Informe de Especificación de Requerimientos | 2007-09-10 → 2007-09-19 A (+9d) | 2007-09-14 → 2007-09-25 A (+11d) |  | 0% → 100% | 0d → none | 3 → 5 |  |
| 8 | Entrega al Equipo de Proyecto Sodexho para su revisión | 2007-09-14 → 2007-09-25 A (+11d) | 2007-09-14 → 2007-09-25 A (+11d) |  | 0% → 100% | 0d → none |  |  |
| 9 | Revisión por parte del Equipo de Proyecto Sodexho | 2007-09-14 → 2007-09-25 A (+11d) | 2007-09-18 → 2007-09-27 A (+9d) |  | 0% → 100% | 0d → none |  |  |
| 10 | Aprobación del Informe Especificación de Requerimientos | 2007-09-18 → 2007-09-27 A (+9d) | 2007-09-18 → 2007-09-27 A (+9d) |  | 0% → 100% | 0d → none |  |  |
| 11 | **Diseño Website e implementación WIB** | 2007-09-11 A | 2007-10-30 → 2007-11-16 (+17d) | 34d? → 47.97d? | 0% → 37% | 2.25d → 6.24d |  |  |
| 12 | **WIB** | 2007-09-11 A | 2007-10-17 → 2007-11-06 (+20d) | 25.5d? → 39.47d? | 0% → 52% | 2.25d → 6.24d |  |  |
| 14 | **Diseño Pagina Principal** | 2007-09-11 → 2007-09-14 A (+3d) | 2007-09-14 → 2007-09-20 A (+6d) | 3d? → 3.5d? | 0% → 100% | 2.25d → none |  |  |
| 15 | Despliegue de Artículos (Lo último) | 2007-09-11 → 2007-09-14 A (+3d) | 2007-09-11 → 2007-09-17 A (+6d) | 0.5d? → 0.31d? | 0% → 100% | 2.25d → none | 4 → 13 | was named Proximos Eventos; resources FA [50%] → FA [80%] |
| 18 | Calendario | 2007-09-13 → 2007-09-19 A (+6d) | 2007-09-13 → 2007-09-19 A (+6d) | 0.75d? → 0.47d? | 0% → 100% | 2.25d → none | 19 → 17 | resources FA [50%] → FA [80%] |
| 19 | Enlaces a Salas | 2007-09-12 → 2007-09-19 A (+7d) | 2007-09-12 → 2007-09-20 A (+8d) | 0.5d? → 0.31d? | 0% → 100% | 2.25d → none | Lo Ultimo → 18 | resources FA [50%] → FA [80%] |
| 20 | Aliados | 2007-09-13 → 2007-09-20 A (+7d) | 2007-09-14 → 2007-09-20 A (+6d) | 0.5d? → 0.31d? | 0% → 100% | 2.25d → none | 18 → 19 | was named Afiliados; resources FA [50%] → FA [80%] |
| 21 | **Diseño Salas** | 2007-09-19 → 2007-09-18 A (-1d) |  | 4.5d? → 6.09d? | 0% → 78% | 2.25d → 34.39d |  |  |
| 22 | Ultimos 6 Elementos de Información | 2007-09-21 → 2007-09-18 A (-3d) | 2007-09-24 → 2007-09-19 A (-5d) | 1.5d? → 0.94d? | 0% → 100% | 2.25d → none | 24 → 16 | resources FA [50%] → FA [80%] |
| 23 | Descripcion de la Sala (Parrafo Libre) | 2007-09-19 → 2007-09-20 A (+1d) | 2007-09-19 → 2007-09-20 A (+1d) | 0.25d? → 0.16d? | 0% → 100% | 2.25d → none |  | resources FA [50%] → FA [80%] |
| 24 | Blog (Paquetizado) | 2007-09-20 A | 2007-09-20 → 2007-09-21 A (+1d) | 1d? → 0.62d? | 0% → 100% | 2.25d → none |  | resources FA [50%] → FA [80%] |
| 25 | **Buscador Avanzado de Artículos** | 2007-09-24 → 2007-09-25 A (+1d) |  | 1.75d? → 1.09d? | 0% → 43% | 2.25d → 34.39d |  | was named Buscador Avanzado |
| 26 | Formulario | 2007-09-24 → 2007-09-25 A (+1d) | 2007-09-25 A | 0.75d? → 0.47d? | 0% → 100% | 2.25d → none | 22 → 44 | resources FA [50%] → FA [80%] |
| 27 | Resultados |  |  | 1d? → 0.62d? |  | 2.25d → 34.39d |  | resources FA [50%] → FA [80%] |
| 28 | **Encuestas** | 2007-10-10 → 2007-09-28 A (-12d) | 2007-10-10 → 2007-10-01 A (-9d) |  | 0% → 100% | 2.25d → none |  |  |
| 29 | Formato de Encuestas | 2007-10-10 → 2007-09-28 A (-12d) | 2007-10-10 → 2007-10-01 A (-9d) |  | 0% → 100% | 2.25d → none | 32 → none |  |
| 30 | **Mapa del Sitio** | 2007-10-09 → 2007-10-04 A (-5d) | 2007-10-09 → 2007-10-05 A (-4d) |  | 0% → 100% | 2.25d → none |  |  |
| 31 | Mapa del Sitio | 2007-10-09 → 2007-10-04 A (-5d) | 2007-10-09 → 2007-10-05 A (-4d) |  | 0% → 100% | 2.25d → none | 34 → none |  |
| 32 | **Quien es Quien** | 2007-10-09 → 2007-10-05 A (-4d) | 2007-10-09 → 2007-10-05 A (-4d) |  | 0% → 100% | 2.25d → none |  |  |
| 33 | Formato de Hoja de Vida | 2007-10-09 → 2007-10-05 A (-4d) | 2007-10-09 → 2007-10-05 A (-4d) |  | 0% → 100% | 2.25d → none | 30 → none |  |
| 34 | **Formularios** | 2007-10-04 → 2007-10-24 (+20d) | 2007-10-09 → 2007-10-25 (+16d) | 3d? → 1.88d? |  | 2.25d → 11.8d |  |  |
| 35 | Formulario de Contacto | 2007-10-04 → 2007-10-24 (+20d) | 2007-10-05 → 2007-10-24 (+19d) | 1.5d? → 0.94d? |  | 2.25d → 11.8d | 51 → none | constraint none → start no earlier than 2007-10-24; resources FA [50%] → FA [80%] |
| 36 | Formulario de Registro | 2007-10-05 → 2007-10-24 (+19d) | 2007-10-09 → 2007-10-25 (+16d) | 1.5d? → 0.94d? |  | 2.25d → 11.8d |  | resources FA [50%] → FA [80%] |
| 37 | Mensaje de Información para Usuario | 2007-09-19 → 2007-10-25 (+36d) | 2007-09-19 → 2007-10-26 (+37d) | 0.5d? → 0.31d? |  | 2.25d → 11.8d | 44 → 34 | resources FA [50%] → FA [80%] |
| 38 | Encabezado para Mail | 2007-09-28 → 2007-10-26 (+28d) | 2007-10-01 → 2007-10-26 (+25d) | 0.5d? → 0.31d? |  | 2.25d → 11.8d | 40 → 37 | resources FA [50%] → FA [80%] |
| 39 | **Informacion Util** | 2007-09-26 → 2007-10-26 (+30d) | 2007-09-26 → 2007-10-29 (+33d) | 0.5d? → 1.41d? |  | 2.25d → 11.8d |  |  |
| 40 | **Servicios** | 2007-09-26 → 2007-10-26 (+30d) | 2007-09-28 → 2007-10-29 (+31d) | 2d? → 1.25d? |  | 2.25d → 11.8d |  |  |
| 41 | Buscador | 2007-09-26 → 2007-10-26 (+30d) | 2007-09-27 → 2007-10-29 (+32d) | 1d? → 0.62d? |  | 2.25d → 11.8d | 39 → 38 | resources FA [50%] → FA [80%] |
| 42 | Pagina Detalle | 2007-09-27 → 2007-10-29 (+32d) | 2007-09-28 → 2007-10-29 (+31d) | 1d? → 0.62d? |  | 2.25d → 11.8d |  | resources FA [50%] → FA [80%] |
| 44 | **Diseño Eventos** | 2007-09-14 → 2007-09-21 A (+7d) | 2007-09-19 → 2007-10-31 (+42d) | 2.75d? → 26.59d? | 0% → 36% | 2.25d → 6.24d |  |  |
| 45 | Listado de Eventos | 2007-09-14 → 2007-09-21 A (+7d) | 2007-09-14 → 2007-09-21 A (+7d) | 0.5d? → 0.31d? | 0% → 100% | 2.25d → none | 14 → 24 | resources FA [50%] → FA [80%] |
| 46 | Detalle de los Eventos | 2007-09-17 → 2007-09-21 A (+4d) | 2007-09-17 → 2007-09-24 A (+7d) | 0.5d? → 0.31d? | 0% → 100% | 2.25d → none |  | resources FA [50%] → FA [80%] |
| 47 | Planilla de Inscripción | 2007-09-17 → 2007-10-30 (+43d) | 2007-09-18 → 2007-10-30 (+42d) | 0.75d? → 0.47d? |  | 2.25d → 6.24d | 46 → none | constraint none → start no earlier than 2007-10-30; resources FA [50%] → FA [80%] |
| 48 | Proforma de Pago de Evento | 2007-09-18 → 2007-10-30 (+42d) | 2007-09-19 → 2007-10-31 (+42d) | 1d? → 0.62d? |  | 2.25d → 6.24d |  | was named Planilla de Pago; resources FA [50%] → FA [80%] |
| 49 | **Formatos** | 2007-10-01 → 2007-10-31 (+30d) | 2007-10-01 → 2007-10-31 (+30d) | 0.5d? → 0.31d? |  | 2.25d → 6.24d |  |  |
| 50 | Lista de documentos disponibles para ser descargados | 2007-10-01 → 2007-10-31 (+30d) | 2007-10-01 → 2007-10-31 (+30d) | 0.5d? → 0.31d? |  | 2.25d → 6.24d | 38 → 44 | resources FA [50%] → FA [80%] |
| 51 | **Herramientas** | 2007-10-01 → 2007-10-31 (+30d) | 2007-10-04 → 2007-11-01 (+28d) | 2.5d? → 1.56d? |  | 2.25d → 6.24d |  |  |
| 52 | Calculadora de Inflacion | 2007-10-01 → 2007-10-31 (+30d) | 2007-10-02 → 2007-11-01 (+30d) | 1.25d? → 0.78d? |  | 2.25d → 6.24d |  | resources FA [50%] → FA [80%] |
| 53 | Calculadora Financiera | 2007-10-03 → 2007-11-01 (+29d) | 2007-10-04 → 2007-11-01 (+28d) | 1.25d? → 0.78d? |  | 2.25d → 6.24d |  | resources FA [50%] → FA [80%] |
| 54 | **Plantillas de Contenido** | 2007-10-11 → 2007-11-01 (+21d) | 2007-10-17 → 2007-11-06 (+20d) | 4d? → 2.5d? |  | 2.25d → 6.24d |  | was named Plantillas |
| 55 | Plantilla 1 | 2007-10-11 → 2007-11-01 (+21d) | 2007-10-11 → 2007-11-02 (+22d) | 1d? → 0.62d? |  | 2.25d → 6.24d | 28 → 51 | resources FA [50%] → FA [80%] |
| 56 | Plantilla 2 | 2007-10-15 → 2007-11-02 (+18d) | 2007-10-15 → 2007-11-05 (+21d) | 1d? → 0.62d? |  | 2.25d → 6.24d |  | resources FA [50%] → FA [80%] |
| 57 | Plantilla 3 | 2007-10-16 → 2007-11-05 (+20d) | 2007-10-16 → 2007-11-05 (+20d) | 1d? → 0.62d? |  | 2.25d → 6.24d |  | resources FA [50%] → FA [80%] |
| 58 | Plantilla 4 | 2007-10-17 → 2007-11-05 (+19d) | 2007-10-17 → 2007-11-06 (+20d) | 1d? → 0.62d? |  | 2.25d → 6.24d |  | resources FA [50%] → FA [80%] |
| 59 | **Net2Client** | 2007-10-18 → 2007-11-06 (+19d) | 2007-10-22 → 2007-11-08 (+17d) |  |  | 2.25d → 6.24d |  |  |
| 60 | Revision y Adaptacion de CSS de Backoffice | 2007-10-18 → 2007-11-06 (+19d) | 2007-10-22 → 2007-11-08 (+17d) |  |  | 2.25d → 6.24d | 54 → 12 |  |
| 61 | Adaptacion de Hoja a Firefox | 2007-10-22 → 2007-11-08 (+17d) | 2007-10-30 → 2007-11-16 (+17d) |  |  | 2.25d → 6.24d |  |  |
| 62 | **Desarrollo y Configuración de Funcionalidades** | 2007-09-11 A | 2007-10-23 → 2007-11-12 (+20d) | 29.23d? → 44d? | 0% → 62% | 0.9d → 0d |  |  |
| 63 | **Análisis y Diseño de funcionalidades y backoffice** | 2007-09-11 A | 2007-09-17 → 2007-10-05 A (+18d) | 3.6d → 19d | 0% → 100% | 0.9d → none |  |  |
| 64 | Análisis | 2007-09-11 A | 2007-09-13 → 2007-10-05 A (+22d) | 1.6d → 17d | 0% → 100% | 0.9d → none | 4 → none | constraint none → start no earlier than 2007-09-11; resources DS1; GP [25%] → DS1 [10%]; GP [10%] |
| 65 | Modelaje de Base de Datos | 2007-09-13 → 2007-09-17 A (+4d) | 2007-09-17 → 2007-09-25 A (+8d) | 2d → 7d | 0% → 100% | 1.82d → none | 64 → none | constraint none → start no earlier than 2007-09-17; resources GP [25%]; DS1 → GP [10%]; DS1 [10%] |
| 66 | **Funcionalidades del Sitio Web** | 2007-09-17 → 2007-09-13 A (-4d) | 2007-10-23 → 2007-11-12 (+20d) | 25.62d? → 42d? | 0% → 45% | 1.82d → 0d |  |  |
| 67 | **BackOffice** | 2007-09-17 → 2007-09-13 A (-4d) | 2007-10-01 → 2007-10-29 (+28d) | 10d? → 31.19d? | 0% → 81% | 1.82d → 10.81d |  |  |
| 68 | Registro y Actualización de Cursos | 2007-09-17 → 2007-09-13 A (-4d) | 2007-09-17 → 2007-09-13 (-4d) |  | 0% → 80% | 11.2d → 41.38d | 63 → none | constraint none → start no earlier than 2007-09-13 |
| 69 | Creación y Configuración de Salas | 2007-09-17 A | 2007-09-18 → 2007-09-17 A (-1d) | 1.25d? → 0.71d? | 0% → 100% | 8.07d → none | 63 → none | constraint none → start no earlier than 2007-09-17; resources DS1 [80%] → DS1 [70%] |
| 70 | Registro de Artículos | 2007-09-18 → 2007-09-17 A (-1d) | 2007-09-19 A | 1.25d? → 1.67d? | 0% → 100% | 8.07d → none |  | was named Artículos por Sala; resources DS1 [80%] → DS1 [60%] |
| 71 | Administración de Banners | 2007-09-19 → 2007-09-25 A (+6d) | 2007-09-24 → 2007-09-26 A (+2d) |  | 0% → 100% | 6.07d → none | 70 → 96 |  |
| 72 | Manejo de Contenido de Artículos de Blogs | 2007-09-18 → 2007-09-27 A (+9d) | 2007-09-26 → 2007-10-01 A (+5d) | 4d → 1.25d | 0% → 100% | 1.82d → none | 74 → 79 | resources DS2 [50%] → DS1 [80%] |
| 73 | Módulo Contáctenos | 2007-09-28 → 2007-10-03 A (+5d) | 2007-10-01 → 2007-10-04 A (+3d) | 1d? → 0.62d? | 0% → 100% | 1.82d → none | 113 → 97 | resources DS2 [50%] → DS1 [80%] |
| 74 | Registro de Servicios | 2007-09-17 → 2007-10-26 (+39d) | 2007-09-18 → 2007-10-29 (+41d) | 1d? → 0.62d? |  | 1.82d → 9.56d | 63 → 87 | resources DS2 [50%] → DS1 [80%] |
| 76 | **General** | 2007-10-01 → 2007-09-26 A (-5d) | 2007-10-08 → 2007-10-26 (+18d) | 5d? → 21.24d? | 0% → 48% | 1.82d → 1.25d |  |  |

| ID | Task | Start | Finish | Duration | Complete | Total float | Predecessors | Other |
| --- | --- | --- | --- | --- | --- | --- | --- | --- |
| 77 | Registro de Cliente | 2007-10-01 → 2007-10-23 (+22d) | 2007-10-02 → 2007-10-25 (+23d) | 1.25d → 2.5d |  | 1.82d → 1.25d | 67 → none | constraint none → start no earlier than 2007-10-23; resources DS1 [80%] → DS2 [40%] |
| 78 | Login | 2007-10-02 → 2007-10-25 (+23d) | 2007-10-02 → 2007-10-26 (+24d) | 0.62d? → 1.25d? |  | 1.82d → 1.25d |  | resources DS1 [80%] → DS2 [40%] |
| 79 | Banners | 2007-10-03 → 2007-09-26 A (-7d) | 2007-10-08 → 2007-09-27 A (-11d) | 2.5d? → 1.25d? | 0% → 100% | 1.82d → none | 82 → 71 |  |
| 80 | Contáctanos | 2007-10-02 → 2007-10-04 A (+2d) | 2007-10-03 → 2007-10-04 A (+1d) | 0.62d? → 0.39d? | 0% → 100% | 5.95d → none | 83 → 73 | resources DS2 [50%] → DS1 [80%] |
| 81 | Tópico de Interés | 2007-10-01 → 2007-10-04 A (+3d) | 2007-10-01 → 2007-10-04 A (+3d) | 0.62d? → 0.39d? | 0% → 100% | 5.95d → none | 73 → 80 | resources DS2 [50%] → DS1 [80%] |
| 82 | Buscador General | 2007-10-02 → 2007-10-11 A (+9d) | 2007-10-03 → 2007-10-11 A (+8d) |  | 0% → 100% | 1.82d → none | 78 → 98 |  |
| 83 | Encuestas | 2007-10-01 → 2007-10-02 A (+1d) | 2007-10-02 A | 1.25d? → 0.78d? | 0% → 100% | 5.95d → none | 81 → 88 | resources DS2 [50%] → DS3 [80%] |
| 84 | **Página Principal** | 2007-09-17 → 2007-09-19 A (+2d) | 2007-10-09 → 2007-10-26 (+17d) | 16.25d? → 26.18d? | 0% → 57% | 4.32d → 9.56d |  |  |
| 85 | Lo último (artículos de información recientes) | 2007-10-08 → 2007-09-19 A (-19d) | 2007-10-09 → 2007-09-24 A (-15d) |  | 0% → 100% | 1.82d → none | Lo que viene (despliegue de datos básicos de hasta 3 eventos) → 70 |  |
| 86 | Enlaces a las salas | 2007-10-09 → 2007-10-04 A (-5d) | 2007-10-09 → 2007-10-05 A (-4d) |  | 0% → 100% | 1.82d → none | 85 → 81 |  |
| 87 | Aliados (5 random) | 2007-10-03 → 2007-10-25 (+22d) | 2007-10-08 → 2007-10-26 (+18d) | 2.5d? → 0.94d? |  | 5.95d → 9.56d | Mapa del Sitio → 75 | was named Afiliados (5 random); resources DS2 [50%] → DS1 [80%] |
| 88 | **Eventos** | 2007-09-24 → 2007-09-13 A (-11d) | 2007-10-04 → 2007-11-12 (+39d) | 7.5d? → 41.38d? | 0% → 34% | 14.32d → 0d |  |  |
| 89 | Calendario de Eventos | 2007-09-17 → 2007-09-13 A (-4d) | 2007-09-24 → 2007-09-20 A (-4d) |  | 0% → 100% | 14.32d → none |  |  |
| 90 | Publicación de Cursos | 2007-09-24 → 2007-09-20 A (-4d) | 2007-09-25 → 2007-09-21 A (-4d) |  | 0% → 100% | 14.32d → none |  |  |
| 91 | Inscripción en Evento | 2007-09-25 → 2007-10-29 (+34d) | 2007-10-02 → 2007-11-02 (+31d) | 5.62d? → 5d? |  | 14.32d → 0d | 90 → none | was named Inscripción y registro de pago de cursos; constraint none → start no earlier than 2007-10-29; resources DS3 [80%] → DS3 [50%] |
| 93 | Reservación de Cupo | 2007-10-02 → 2007-11-07 (+36d) | 2007-10-04 → 2007-11-08 (+35d) | 1.25d? → 2d? |  | 14.32d → 0d | 91 → 92 | was named Reservación y vencimiento; resources DS3 [80%] → DS3 [50%] |
| 95 | **Salas** | 2007-10-08 → 2007-09-24 A (-14d) | 2007-10-19 → 2007-10-11 A (-8d) | 8.5d? → 13.28d? | 0% → 100% | 2.45d → none |  |  |
| 96 | Lo Último (los 6 elementos de información recientes) | 2007-10-09 → 2007-09-24 A (-15d) | 2007-10-15 → 2007-09-25 A (-20d) | 2.5d? → 1.25d? | 0% → 100% | 1.82d → none | 86 → 85 |  |
| 97 | Blog | 2007-10-08 → 2007-10-01 A (-7d) | 2007-10-10 → 2007-10-03 A (-7d) |  | 0% → 100% | 5.95d → none | 87 → 72 | resources DS2 [50%] → DS1 [50%] |
| 98 | Buscador | 2007-10-15 → 2007-10-05 A (-10d) | 2007-10-19 → 2007-10-11 A (-8d) |  | 0% → 100% | 1.82d → none | 96 → 86 |  |
| 103 | **Información Útil** | 2007-10-16 → 2007-10-29 (+13d) | 2007-10-23 → 2007-11-05 (+13d) | 5.38d? → 5.44d? |  | 1.82d → 5.38d |  |  |
| 104 | Herramientas | 2007-10-19 → 2007-11-05 (+17d) | 2007-10-22 → 2007-11-05 (+14d) |  |  | 1.82d → 5.38d | Artículo aleatorio en Columna Derecha → none | constraint none → start no earlier than 2007-11-05; resources DS1 [80%] → DS3 [80%] |
| 105 | Servicios | 2007-10-22 → 2007-10-29 (+7d) | 2007-10-23 → 2007-10-30 (+7d) |  |  | 1.82d → 9.56d | 104 → 74 |  |
| 106 | Carga de datos de Clientes en .CSV | 2007-10-23 → 2007-10-30 (+7d) | 2007-10-26 → 2007-10-31 (+5d) | 3d? → 1.5d? |  | 4.03d → 18.27d | 66 → 105 | resources GP [50%] → DS1 |
| 107 | Pruebas Internas y ajustes | 2007-10-23 → 2007-11-13 (+21d) | 2007-10-24 → 2007-11-14 (+21d) | 0.95d → 1.54d |  | 1.82d → 0d |  | resources DS1; GP [5%] → DS1 [50%]; GP [5%]; DS3 [25%] |
| 108 | Pruebas de Certificación por parte del Cliente | 2007-10-24 → 2007-11-14 (+21d) | 2007-10-29 → 2007-11-15 (+17d) | 3d → 1d |  | 1.82d → 0.54d |  |  |
| 109 | Pase a Producción | 2007-10-29 → 2007-11-15 (+17d) | 2007-10-30 → 2007-11-16 (+17d) |  |  | 1.82d → 0.54d |  | was named Implementación (Pase a producción) |
| 111 | Guia de Usuario BackOffice | 2007-10-24 → 2007-11-14 (+21d) | 2007-10-26 → 2007-11-23 (+28d) | 2d → 6.67d |  | 3.07d → 0d |  | resources GP [50%] → GP [15%] |
| 112 | Inducción (preparación y adiestramiento) | 2007-10-26 → 2007-11-23 (+28d) | 2007-10-29 → 2007-11-26 (+28d) |  |  | 3.07d → 0d |  |  |
| 113 | Registro de Quién es Quién | 2007-09-26 → 2007-11-16 (+51d) | 2007-09-28 → 2007-11-21 (+54d) | 2d? → 2.5d? |  | 1.82d → 0.54d | 72 → 109 | was named Quién es Quién; resources DS2 [50%] → DS2 [40%] |
| 114 | Despliegue de Quién es quién | 2007-10-10 → 2007-11-21 (+42d) | 2007-10-16 → 2007-11-26 (+41d) | 2.5d? → 3.12d? |  | 5.95d → 0.54d | 97 → 113 | was named Quién es quién; resources DS2 [50%] → DS2 [40%] |
| 116 | **Gerencia de Proyectos** | 2007-09-18 → 2007-09-04 (-14d) | 2007-11-01 → 2007-11-27 (+26d) | 31.25d → 58.83d? |  |  |  |  |
| 117 | Control y Seguimiento | 2007-09-18 → 2007-09-04 (-14d) | 2007-11-01 → 2007-11-21 (+20d) | 31.25d → 55.36d? |  | 0d → 3.47d | 6 → 2 | resources GP [10%] → GP [7%] |
| 118 | Cierre | 2007-10-30 → 2007-11-26 (+27d) | 2007-10-30 → 2007-11-27 (+28d) | 0.25d → 1d? |  | 1.82d → 0d | 109 → 112 |  |
